# cronograma VI

Schedule from MS Project, 2007-10-08 to 2008-02-29, status date 2007-11-05, A marks actual dates.
QUIVAL

## Calendars

- Estándar: Mon-Fri 09:00-13:00, 15:00-19:00; Sat-Sun off.

## Resources

| Resource |
| --- |
| Alumnos del grupo |
| Docente asignatura rectora |
| Docente responsable |
| Docentes del nivel |
| COMISIÓN EVALUADORA |

## Schedule

| ID | WBS | Task | Duration | Start | Finish | Predecessors | Complete | Total slack | Free slack | Constraint | Resources | Work | Actual work |
| --- | --- | --- | --- | --- | --- | --- | --- | --- | --- | --- | --- | --- | --- |
| 1 | 1 | Socialización | 5d | 2007-10-08 A | 2007-10-12 A |  | 100% |  |  | finish no earlier than 2007-04-13 | Docentes del nivel | 40h | 40h |
| 2 | 2 | Aprobación del tema | 5d | 2007-10-15 A | 2007-10-19 A | 1 | 100% |  |  | start no earlier than 2006-10-16 | Docente asignatura rectora | 40h | 40h |
| 3 | 3 | Recopilación de información básica | 5d | 2007-10-22 A | 2007-10-26 A | 2FS+2d | 100% |  |  | start no earlier than 2006-10-23 | Alumnos del grupo | 40h | 40h |
| 4 | 4 | Elaboración del plan | 1d | 2007-10-29 A | 2007-10-29 A | 3 | 100% |  |  | start no earlier than 2007-04-30 | Alumnos del grupo | 8h | 8h |
| 5 | 5 | Elaboración del estudio preliminar | 1d | 2007-10-30 A | 2007-10-30 A | 4 | 100% |  |  |  | Alumnos del grupo | 8h | 8h |
| 6 | 6 | Ajustes del plan y estudio preliminar | 1d | 2007-10-31 A | 2007-10-31 A | 5 | 100% |  |  | finish no earlier than 2007-05-02 | Docente responsable | 8h | 8h |
| 7 | 7 | Entrega de plan y estudio preliminar | 1d | 2007-11-05 A | 2007-11-05 A | 6 | 100% |  |  | start no earlier than 2006-11-08 | Alumnos del grupo | 8h | 8h |
| 8 | 8 | Preparación de presentación | 1d | 2007-11-06 A | 2007-11-06 A | 7 | 100% |  |  | finish no earlier than 2007-05-08 | Alumnos del grupo | 8h | 8h |
| 9 | 9 | Primera presentación PI | 3d | 2007-11-07 | 2007-11-09 | 8 |  | 75d | 0d | start no earlier than 2007-05-09 | COMISIÓN EVALUADORA | 24h |  |
| 10 | 10 | Procesamiento de información bibliográfica | 5d | 2007-11-12 | 2007-11-16 | 9 |  | 75d |  | start no earlier than 2006-11-13 | Alumnos del grupo | 40h |  |
| 11 | 11 | Ing. Sistema y análisis de información | 30d | 2007-11-12 | 2007-12-21 |  |  | 50d |  | start no earlier than 2007-11-12 | Docente responsable | 240h |  |
| 12 | 12 | Definición de modelos | 9d | 2007-11-26 | 2007-12-06 |  |  | 51d | 0d | start no earlier than 2007-11-25 | Alumnos del grupo | 72h |  |
| 13 | 13 | Elaboración de prototipo | 5d | 2007-12-07 | 2007-12-13 | 12 |  | 51d | 0d | start no earlier than 2007-06-04 | Alumnos del grupo | 40h |  |
| 14 | 14 | Implementación de modelos, objetos | 5d | 2007-12-17 | 2007-12-21 | 13 |  | 50d |  | start no earlier than 2007-12-17 | Alumnos del grupo | 40h |  |
| 15 | 15 | Diseño de interfaces simples | 3d | 2007-12-13 | 2007-12-17 | 16 |  | 54d |  |  | Alumnos del grupo | 24h |  |
| 16 | 16 | Diseño de interfaces secundarias | 3d | 2007-12-10 | 2007-12-12 |  |  | 54d | 0d | start no earlier than 2007-12-09 | Alumnos del grupo | 24h |  |
| 17 | 17 | Diseño de interfaces de mantenimiento | 3d | 2007-12-10 | 2007-12-12 |  |  | 32d | 7d | start no earlier than 2007-12-10 | Alumnos del grupo | 24h |  |
| 18 | 18 | Implementación de interfaces y conexiones | 5d | 2007-12-24 | 2007-12-28 | 17 |  | 45d |  | start no earlier than 2007-12-23 | Alumnos del grupo | 40h |  |
| 19 | 19 | Elaboración documento con análisis y diseño | 12d | 2007-12-17 | 2008-01-01 |  |  | 7d | 0d | start no earlier than 2007-12-17 | Alumnos del grupo | 96h |  |
| 20 | 21 | Segunda presentación PI | 3d | 2008-01-02 | 2008-01-04 | 19 |  | 7d | 0d | start no earlier than 2007-07-11 | COMISIÓN EVALUADORA | 24h |  |
| 21 | 21 | Implementación de procedimientos | 10d | 2007-12-31 | 2008-01-11 | 14 |  | 20d | 0d | start no earlier than 2007-12-30 | Alumnos del grupo | 80h |  |
| 22 | 22 | Implementación de reportes | 10d | 2008-01-07 | 2008-01-18 | 11 |  | 30d |  | start no earlier than 2008-01-06 | Alumnos del grupo | 80h |  |
| 23 | 23 | Implementación de ayudas | 5d | 2008-01-14 | 2008-01-18 | 21 |  | 20d | 0d |  | Alumnos del grupo | 40h |  |
| 24 | 24 | Implementación de búsquedas | 10d | 2008-01-21 | 2008-02-01 | 23 |  | 20d |  | start no earlier than 2007-01-29 | Alumnos del grupo | 80h |  |
| 25 | 25 | Optimización - Ajustes globales | 20d | 2007-12-31 | 2008-01-25 | 18 |  | 25d |  |  | Alumnos del grupo | 160h |  |
| 26 | 26 | Pruebas | 15d | 2008-01-28 | 2008-02-15 |  |  | 10d |  | finish no earlier than 2008-02-15 |  |  |  |
| 27 | 27 | Elaboración del informe final | 15d | 2008-01-31 | 2008-02-20 |  |  | 4d |  | finish no earlier than 2008-02-20 | Alumnos del grupo | 120h |  |
| 28 | 28 | Publicación en Web | 5d | 2008-02-18 | 2008-02-22 |  |  | 2d |  | finish no earlier than 2008-02-22 |  |  |  |
| 29 | 29 | Defensa final PI | 3d | 2008-02-27 | 2008-02-29 | 28 |  | 0d |  | must finish on 2008-02-29 | COMISIÓN EVALUADORA | 24h |  |
